# paryab

Schedule from MS Project, 2019-04-22 to 2022-04-14, status date 2021-08-23, A marks actual dates.
softsara.ir

## Calendars

- Standard: Mon-Thu 08:00-12:00, 13:00-17:00; Fri off; Sat-Sun 08:00-12:00, 13:00-17:00.

## Schedule

| ID | WBS | Task | Type | Duration | Start | Finish | Predecessors | Complete | Remaining | Baseline start | Baseline finish | Baseline duration | Total slack | Free slack | Constraint | شروع | پایان |
| --- | --- | --- | --- | --- | --- | --- | --- | --- | --- | --- | --- | --- | --- | --- | --- | --- | --- |
| 1 | 1 | **تکمیل دانش فنی و پشتیبانی از ساخت سیستم رانش یک دستگاه قطار هفت واگنه مترو** |  | 934d | 2019-04-22 A | 2022-04-14 |  | 79% | 196.7d | 2019-04-22 | 2022-04-18 | 937d | 0d |  |  | 1398/02/02 | 1401/01/25 |
| 2 | 1.1 | شروع | milestone | 0d | 2019-04-22 A | 2019-04-22 A |  | 100% |  | 2019-04-22 | 2019-04-22 | 0d |  |  |  | 1398/02/02 | 1398/02/02 |
| 3 | 1.2 | تامین بوژی های باقیمانده از طرف شرکت مپنا | milestone | 0d | 2021-08-23 | 2021-08-23 | 2 |  |  | 2021-07-23 | 2021-07-23 | 0d | 0d |  | must start on 2021-08-23 | 1400/06/01 | 1400/06/01 |
| 4 | 1.3 | معرفی مشاور خارجی کارفرما | milestone | 0d | 2021-08-23 | 2021-08-23 |  |  |  | 2021-07-23 | 2021-07-23 | 0d | 0d |  | must start on 2021-08-23 | 1400/06/01 | 1400/06/01 |
| 5 | 1.4 | **فعالیتهای مربوط به پیش از قرارداد و عقد قرارداد** |  | 235d | 2019-04-22 A | 2020-01-20 A |  | 100% |  | 2019-04-22 | 2020-01-20 | 235d |  |  |  | 1398/02/02 | 1398/10/30 |
| 6 | 1.4.1 | مطالعه و بررسی سیستم های رانش موجود در قطارهای متروهای تهران، اصفهان و شیراز |  | 15d | 2019-04-22 A | 2019-05-08 A | 2SS | 100% |  | 2019-04-22 | 2019-05-08 | 15d |  |  |  | 1398/02/02 | 1398/02/18 |
| 7 | 1.4.2 | شبیه سازی و طراحی اولیه الگوریتم های کنترلی |  | 7d | 2019-05-09 A | 2019-05-16 A | 6 | 100% |  | 2019-05-09 | 2019-05-16 | 7d |  |  |  | 1398/02/19 | 1398/02/26 |
| 8 | 1.4.3 | طراحی و ساخت یک نمونه ولتاژ پایین و توان پایین برای ارزیابی نتایج شبیه سازی در بخش کنترل دور موتور |  | 60d | 2019-05-18 A | 2019-07-25 A | 7 | 100% |  | 2019-05-18 | 2019-07-25 | 60d |  |  |  | 1398/02/28 | 1398/05/03 |
| 9 | 1.4.4 | تدوین RFP برد کنترلی تجهیزات ACM و MCM |  | 7d | 2019-07-23 A | 2019-07-30 A | 8FS-3d | 100% |  | 2019-07-23 | 2019-07-30 | 7d |  |  |  | 1398/05/01 | 1398/05/08 |
| 10 | 1.4.5 | شبیه سازی الگوریتم کنترلی سیستم MCM |  | 7d | 2019-07-31 A | 2019-08-07 A | 9 | 100% |  | 2019-07-31 | 2019-08-07 | 7d |  |  |  | 1398/05/09 | 1398/05/16 |
| 11 | 1.4.6 | تهیه لیست قطعات با زمان تامین طولانی |  | 7d | 2019-08-08 A | 2019-08-15 A | 10 | 100% |  | 2019-08-08 | 2019-08-15 | 7d |  |  |  | 1398/05/17 | 1398/05/24 |
| 12 | 1.4.7 | شناسایی سازندگان داخلی برای طراحی و ساخت ترکشن موتور |  | 7d | 2019-07-23 A | 2019-07-30 A | 8FS-3d | 100% |  | 2019-07-23 | 2019-07-30 | 7d |  |  |  | 1398/05/01 | 1398/05/08 |
| 13 | 1.4.8 | شناسایی سازندگان داخلی برای طراحی و ساخت گیربکس |  | 7d | 2019-07-23 A | 2019-07-30 A | 8FS-3d | 100% |  | 2019-07-23 | 2019-07-30 | 7d |  |  |  | 1398/05/01 | 1398/05/08 |
| 14 | 1.4.9 | شناسایی سازندگان داخلی برای طراحی و ساخت مقاومت های ترمزی |  | 7d | 2019-07-23 A | 2019-07-30 A | 8FS-3d | 100% |  | 2019-07-23 | 2019-07-30 | 7d |  |  |  | 1398/05/01 | 1398/05/08 |
| 15 | 1.4.10 | دریافت پیش نویس قرارداد یک رام قطار نمونه ملی | milestone | 0d | 2019-04-22 A | 2019-04-22 A | 2SS | 100% |  | 2019-04-22 | 2019-04-22 | 0d |  |  |  | 1398/02/02 | 1398/02/02 |
| 16 | 1.4.11 | طراحی مفهومی و پایه اولیه سیستم رانش بر اساس مشخصات کلی یک رام قطار نمونه پیشنهادی متروی تهران |  | 10d | 2019-07-23 A | 2019-08-03 A | 8FS-3d | 100% |  | 2019-07-23 | 2019-08-03 | 10d |  |  |  | 1398/05/01 | 1398/05/12 |
| 17 | 1.4.12 | طراحی نرم افزار و انجام محاسبات تحلیل عملکردی اولیه بر اساس مشخصات خط 7 متروی تهران |  | 102d | 2019-08-04 A | 2019-11-30 A | 16 | 100% |  | 2019-08-04 | 2019-11-30 | 102d |  |  |  | 1398/05/13 | 1398/09/09 |
| 18 | 1.4.13 | تائید نهایی مشخصات فنی اجزای سیستم رانش و تهیه RFP نهایی |  | 93d | 2019-08-14 A | 2019-11-30 A | 17FF | 100% |  | 2019-08-14 | 2019-11-30 | 93d |  |  |  | 1398/05/23 | 1398/09/09 |
| 19 | 1.4.14 | تائید نهایی پیش نویس قرارداد سیستم رانش با شرکت متروی تهران |  | 94d | 2019-08-14 A | 2019-12-01 A | 15, 17SS, 18SS | 100% |  | 2019-08-14 | 2019-12-01 | 94d |  |  |  | 1398/05/23 | 1398/09/10 |
| 20 | 1.4.15 | عقد قرارداد سیستم رانش با شرکت متروی تهران |  | 13d | 2019-12-02 A | 2019-12-16 A | 19 | 100% |  | 2019-12-02 | 2019-12-16 | 13d |  |  |  | 1398/09/11 | 1398/09/25 |
| 21 | 1.4.16 | معرفی مدیر پروزه قرارداد قطار ملی |  | 15d | 2019-12-17 A | 2020-01-02 A | 20 | 100% |  | 2019-12-17 | 2020-01-02 | 15d |  |  |  | 1398/09/26 | 1398/10/12 |
| 22 | 1.4.17 | برگزاری جلسه KOM با معاونت مهندسی پروژه قطار ملی |  | 15d | 2020-01-04 A | 2020-01-20 A | 21 | 100% |  | 2020-01-04 | 2020-01-20 | 15d |  |  |  | 1398/10/14 | 1398/10/30 |
| 23 | 1.5 | **محاسبات تحلیل عملکردی (Performance Analysis)** |  | 668d | 2020-01-21 A | 2022-03-09 |  | 16% | 560.34d | 2020-01-21 | 2022-03-09 | 668d | 31d |  |  | 1398/11/01 | 1400/12/18 |
| 24 | 1.5.1 | تکمیل نرم افزار |  | 40d | 2020-01-21 A | 2020-03-07 A | 22 | 100% |  | 2020-01-21 | 2020-03-07 | 40d |  |  |  | 1398/11/01 | 1398/12/17 |
| 25 | 1.5.2 | استخراج اطلاعات خطوط 3، 4، 6 و 7 متروی تهران |  | 40d | 2020-03-08 A | 2020-04-22 A | 24 | 100% |  | 2020-03-08 | 2020-04-22 | 40d |  |  |  | 1398/12/18 | 1399/02/03 |
| 26 | 1.5.3 | انجام محاسبات تحلیل عملکردی سیستم رانش در خطوط 3، 4، 6 و 7 متروی تهران |  | 40d | 2020-04-23 A | 2021-09-25 | 25FS+414d | 20% | 32d | 2020-04-23 | 2021-09-25 | 40d | 31d | 0d |  | 1399/02/04 | 1400/07/03 |
| 27 | 1.5.4 | اضافه کردن محیط GUI به نرم افزار |  | 142d | 2021-09-26 | 2022-03-09 | 26 |  |  | 2021-09-26 | 2022-03-09 | 142d | 31d |  |  | 1400/07/04 | 1400/12/18 |
| 28 | 1.5.5 | اضافه کردن بانک اطلاعاتی انواع سیستم رانش به نرم افزار |  | 142d | 2021-09-26 | 2022-03-09 | 26 |  |  | 2021-09-26 | 2022-03-09 | 142d | 31d |  |  | 1400/07/04 | 1400/12/18 |
| 29 | 1.5.6 | اضافه کردن قابلیت محاسبات توان مصرفی بالادستی |  | 142d | 2021-09-26 | 2022-03-09 | 26 |  |  | 2021-09-26 | 2022-03-09 | 142d | 31d |  |  | 1400/07/04 | 1400/12/18 |

| ID | WBS | Task | Duration | Start | Finish | Predecessors | Complete | Remaining | Baseline start | Baseline finish | Baseline duration | Total slack | شروع | پایان |
| --- | --- | --- | --- | --- | --- | --- | --- | --- | --- | --- | --- | --- | --- | --- |
| 30 | 1.6 | **تکمیل دانش فنی** | 699d | 2020-01-21 A | 2022-04-14 |  | 89% | 76.2d | 2020-01-21 | 2022-02-07 | 642d | 0d | 1398/11/01 | 1401/01/25 |
| 31 | 1.6.1 | **MCM/ACM** | 642d | 2020-01-21 A | 2022-02-07 |  | 83% | 111.03d | 2020-01-21 | 2022-02-07 | 642d | 57d | 1398/11/01 | 1400/11/18 |
| 32 | 1.6.1.1 | **طراحی پایه** | 67d | 2020-01-21 A | 2020-04-07 A |  | 100% |  | 2020-01-21 | 2020-04-07 | 67d |  | 1398/11/01 | 1399/01/19 |
| 33 | 1.6.1.1.1 | طراحی مکانیکال | 60d | 2020-01-21 A | 2020-03-30 A | 22 | 100% |  | 2020-01-21 | 2020-03-30 | 60d |  | 1398/11/01 | 1399/01/11 |
| 34 | 1.6.1.1.2 | طراحی الکتریکال | 40d | 2020-01-21 A | 2020-03-07 A | 33SS | 100% |  | 2020-01-21 | 2020-03-07 | 40d |  | 1398/11/01 | 1398/12/17 |
| 35 | 1.6.1.1.3 | طراحی جانمایی | 40d | 2020-01-29 A | 2020-03-15 A | 34SS+7d | 100% |  | 2020-01-29 | 2020-03-15 | 40d |  | 1398/11/09 | 1398/12/25 |
| 36 | 1.6.1.1.4 | طراحی نهایی مبدل و ارسال به مشاور | 10d | 2020-03-16 A | 2020-03-26 A | 35 | 100% |  | 2020-03-16 | 2020-03-26 | 10d |  | 1398/12/26 | 1399/01/07 |
| 37 | 1.6.1.1.5 | دریافت تاییدیه از مشاور | 10d | 2020-03-28 A | 2020-04-07 A | 36 | 100% |  | 2020-03-28 | 2020-04-07 | 10d |  | 1399/01/09 | 1399/01/19 |
| 38 | 1.6.1.2 | **طراحی تفصیلی** | 35d | 2020-01-29 A | 2020-03-09 A |  | 100% |  | 2020-01-29 | 2020-03-09 | 35d |  | 1398/11/09 | 1398/12/19 |
| 39 | 1.6.1.2.1 | طراحی ماژول قدرت و باس بار | 14d | 2020-01-29 A | 2020-02-13 A | 34SS+7d | 100% |  | 2020-01-29 | 2020-02-13 | 14d |  | 1398/11/09 | 1398/11/24 |
| 40 | 1.6.1.2.2 | طراحی نقشه ساخت بدنه | 14d | 2020-02-15 A | 2020-03-01 A | 39 | 100% |  | 2020-02-15 | 2020-03-01 | 14d |  | 1398/11/26 | 1398/12/11 |
| 41 | 1.6.1.2.3 | طراحی هیت سینک و سیستم خنک سازی تابلو | 21d | 2020-02-15 A | 2020-03-09 A | 39 | 100% |  | 2020-02-15 | 2020-03-09 | 21d |  | 1398/11/26 | 1398/12/19 |
| 42 | 1.6.1.2.4 | محاسبه سلف و ترانس | 14d | 2020-02-15 A | 2020-03-01 A | 39 | 100% |  | 2020-02-15 | 2020-03-01 | 14d |  | 1398/11/26 | 1398/12/11 |
| 43 | 1.6.1.3 | **طراحی بردهای الکترونیکی** | 240d | 2020-01-21 A | 2020-10-26 A |  | 100% |  | 2020-01-21 | 2020-10-26 | 240d |  | 1398/11/01 | 1399/08/05 |
| 44 | 1.6.1.3.1 | **برد کنترل** | 90d | 2020-01-21 A | 2020-05-04 A |  | 100% |  | 2020-01-21 | 2020-05-04 | 90d |  | 1398/11/01 | 1399/02/15 |
| 45 | 1.6.1.3.1.1 | طراحی مدار | 60d | 2020-01-21 A | 2020-03-30 A | 34SS | 100% |  | 2020-01-21 | 2020-03-30 | 60d |  | 1398/11/01 | 1399/01/11 |
| 46 | 1.6.1.3.1.2 | طراحی شماتیک برد | 15d | 2020-03-31 A | 2020-04-16 A | 45 | 100% |  | 2020-03-31 | 2020-04-16 | 15d |  | 1399/01/12 | 1399/01/28 |
| 47 | 1.6.1.3.1.3 | طراحی مدار چاپی برد | 15d | 2020-04-18 A | 2020-05-04 A | 46 | 100% |  | 2020-04-18 | 2020-05-04 | 15d |  | 1399/01/30 | 1399/02/15 |
| 48 | 1.6.1.3.2 | **برد تغذیه** | 75d | 2020-01-21 A | 2020-04-16 A |  | 100% |  | 2020-01-21 | 2020-04-16 | 75d |  | 1398/11/01 | 1399/01/28 |
| 49 | 1.6.1.3.2.1 | طراحی مدار | 45d | 2020-01-21 A | 2020-03-12 A | 34SS | 100% |  | 2020-01-21 | 2020-03-12 | 45d |  | 1398/11/01 | 1398/12/22 |
| 50 | 1.6.1.3.2.2 | طراحی شماتیک برد | 15d | 2020-03-14 A | 2020-03-30 A | 49 | 100% |  | 2020-03-14 | 2020-03-30 | 15d |  | 1398/12/24 | 1399/01/11 |
| 51 | 1.6.1.3.2.3 | طراحی مدار چاپی برد | 15d | 2020-03-31 A | 2020-04-16 A | 50 | 100% |  | 2020-03-31 | 2020-04-16 | 15d |  | 1399/01/12 | 1399/01/28 |
| 52 | 1.6.1.3.3 | **برد Signal Conditioning و I/Oهای دیجیتال و آنالوگ** | 80d | 2020-01-21 A | 2020-04-22 A |  | 100% |  | 2020-01-21 | 2020-04-22 | 80d |  | 1398/11/01 | 1399/02/03 |
| 53 | 1.6.1.3.3.1 | طراحی مدار | 50d | 2020-01-21 A | 2020-03-18 A | 34SS | 100% |  | 2020-01-21 | 2020-03-18 | 50d |  | 1398/11/01 | 1398/12/28 |
| 54 | 1.6.1.3.3.2 | طراحی شماتیک برد | 15d | 2020-03-19 A | 2020-04-05 A | 53 | 100% |  | 2020-03-19 | 2020-04-05 | 15d |  | 1398/12/29 | 1399/01/17 |
| 55 | 1.6.1.3.3.3 | طراحی مدار چاپی برد | 15d | 2020-04-06 A | 2020-04-22 A | 54 | 100% |  | 2020-04-06 | 2020-04-22 | 15d |  | 1399/01/18 | 1399/02/03 |

| ID | WBS | Task | Duration | Start | Finish | Predecessors | Complete | Baseline start | Baseline finish | Baseline duration | شروع | پایان |
| --- | --- | --- | --- | --- | --- | --- | --- | --- | --- | --- | --- | --- |
| 56 | 1.6.1.3.4 | **برد اینترفیس با TCMS** | 120d | 2020-01-21 A | 2020-06-08 A |  | 100% | 2020-01-21 | 2020-06-08 | 120d | 1398/11/01 | 1399/03/19 |
| 57 | 1.6.1.3.4.1 | طراحی مدار | 90d | 2020-01-21 A | 2020-05-04 A | 34SS | 100% | 2020-01-21 | 2020-05-04 | 90d | 1398/11/01 | 1399/02/15 |
| 58 | 1.6.1.3.4.2 | طراحی شماتیک برد | 15d | 2020-05-05 A | 2020-05-21 A | 57 | 100% | 2020-05-05 | 2020-05-21 | 15d | 1399/02/16 | 1399/03/01 |
| 59 | 1.6.1.3.4.3 | طراحی مدار چاپی برد | 15d | 2020-05-23 A | 2020-06-08 A | 58 | 100% | 2020-05-23 | 2020-06-08 | 15d | 1399/03/03 | 1399/03/19 |
| 60 | 1.6.1.3.5 | **برد فیبر نوری فرمان به درایور نیمه هادی ها** | 70d | 2020-01-21 A | 2020-04-11 A |  | 100% | 2020-01-21 | 2020-04-11 | 70d | 1398/11/01 | 1399/01/23 |
| 61 | 1.6.1.3.5.1 | طراحی مدار | 40d | 2020-01-21 A | 2020-03-07 A | 34SS | 100% | 2020-01-21 | 2020-03-07 | 40d | 1398/11/01 | 1398/12/17 |
| 62 | 1.6.1.3.5.2 | طراحی شماتیک برد | 15d | 2020-03-08 A | 2020-03-24 A | 61 | 100% | 2020-03-08 | 2020-03-24 | 15d | 1398/12/18 | 1399/01/05 |
| 63 | 1.6.1.3.5.3 | طراحی مدار چاپی برد | 15d | 2020-03-25 A | 2020-04-11 A | 62 | 100% | 2020-03-25 | 2020-04-11 | 15d | 1399/01/06 | 1399/01/23 |
| 64 | 1.6.1.3.6 | **برد درایور** | 78d | 2020-01-21 A | 2020-04-20 A |  | 100% | 2020-01-21 | 2020-04-20 | 78d | 1398/11/01 | 1399/02/01 |
| 65 | 1.6.1.3.6.1 | طراحی مدار | 48d | 2020-01-21 A | 2020-03-16 A | 34SS | 100% | 2020-01-21 | 2020-03-16 | 48d | 1398/11/01 | 1398/12/26 |
| 66 | 1.6.1.3.6.2 | طراحی شماتیک برد | 15d | 2020-03-17 A | 2020-04-02 A | 65 | 100% | 2020-03-17 | 2020-04-02 | 15d | 1398/12/27 | 1399/01/14 |
| 67 | 1.6.1.3.6.3 | طراحی مدار چاپی برد | 15d | 2020-04-04 A | 2020-04-20 A | 66 | 100% | 2020-04-04 | 2020-04-20 | 15d | 1399/01/16 | 1399/02/01 |
| 68 | 1.6.1.3.7 | **طراحی نرم افزارها** | 150d | 2020-05-05 A | 2020-10-26 A |  | 100% | 2020-05-05 | 2020-10-26 | 150d | 1399/02/16 | 1399/08/05 |
| 69 | 1.6.1.3.7.1 | FPGA طراحی نرم افزار | 90d | 2020-05-05 A | 2020-08-17 A | 45FS+30d | 100% | 2020-05-05 | 2020-08-17 | 90d | 1399/02/16 | 1399/05/27 |
| 70 | 1.6.1.3.7.2 | TCMS طراحی نرم افزار ارتباط با | 120d | 2020-05-05 A | 2020-09-21 A | 45FS+30d | 100% | 2020-05-05 | 2020-09-21 | 120d | 1399/02/16 | 1399/06/31 |
| 71 | 1.6.1.3.7.3 | DSP طراحی نرم افزار | 150d | 2020-05-05 A | 2020-10-26 A | 45FS+30d | 100% | 2020-05-05 | 2020-10-26 | 150d | 1399/02/16 | 1399/08/05 |
| 72 | 1.6.1.3.8 | **لیست خرید** | 12d | 2020-05-05 A | 2020-05-18 A |  | 100% | 2020-05-05 | 2020-05-18 | 12d | 1399/02/16 | 1399/02/29 |
| 73 | 1.6.1.3.8.1 | شناسایی تامین کنندگان/انتخاب پیمانکار داخلی یا خارجی | 6d | 2020-05-05 A | 2020-05-11 A | 33, 35, 42, 41, 45, 49, 53, 57, 61, 65, 34 | 100% | 2020-05-05 | 2020-05-11 | 6d | 1399/02/16 | 1399/02/22 |
| 74 | 1.6.1.3.8.2 | تهیه لیست خرید | 6d | 2020-05-12 A | 2020-05-18 A | 73 | 100% | 2020-05-12 | 2020-05-18 | 6d | 1399/02/23 | 1399/02/29 |
| 75 | 1.6.1.3.9 | دریافت تاییدیه از مشاور | 10d | 2020-05-19 A | 2020-05-30 A | 72 | 100% | 2020-05-19 | 2020-05-30 | 10d | 1399/02/30 | 1399/03/10 |
| 76 | 1.6.1.4 | **تامین و تدارکات** | 80d | 2020-05-19 A | 2020-08-19 A |  | 100% | 2020-05-19 | 2020-08-19 | 80d | 1399/02/30 | 1399/05/29 |
| 77 | 1.6.1.4.1 | بدنه | 14d | 2020-05-19 A | 2020-06-03 A | 74 | 100% | 2020-05-19 | 2020-06-03 | 14d | 1399/02/30 | 1399/03/14 |
| 78 | 1.6.1.4.2 | هیت سینک | 14d | 2020-05-19 A | 2020-06-03 A | 74 | 100% | 2020-05-19 | 2020-06-03 | 14d | 1399/02/30 | 1399/03/14 |
| 79 | 1.6.1.4.3 | قطعات الکترونیک | 24d | 2020-05-19 A | 2020-06-15 A | 74 | 100% | 2020-05-19 | 2020-06-15 | 24d | 1399/02/30 | 1399/03/26 |
| 80 | 1.6.1.4.4 | قطعات الکترونیک قدرت | 30d | 2020-05-19 A | 2020-06-22 A | 74 | 100% | 2020-05-19 | 2020-06-22 | 30d | 1399/02/30 | 1399/04/02 |
| 81 | 1.6.1.4.5 | باس بار | 21d | 2020-05-19 A | 2020-06-11 A | 74 | 100% | 2020-05-19 | 2020-06-11 | 21d | 1399/02/30 | 1399/03/22 |
| 82 | 1.6.1.4.6 | سیم و کابل | 24d | 2020-05-19 A | 2020-06-15 A | 74 | 100% | 2020-05-19 | 2020-06-15 | 24d | 1399/02/30 | 1399/03/26 |
| 83 | 1.6.1.4.7 | انواع کانکتورها | 21d | 2020-05-19 A | 2020-06-11 A | 74 | 100% | 2020-05-19 | 2020-06-11 | 21d | 1399/02/30 | 1399/03/22 |
| 84 | 1.6.1.4.8 | سلف | 80d | 2020-05-19 A | 2020-08-19 A | 74 | 100% | 2020-05-19 | 2020-08-19 | 80d | 1399/02/30 | 1399/05/29 |
| 85 | 1.6.1.4.9 | بردهای الکترونیک | 15d | 2020-05-19 A | 2020-06-04 A | 74 | 100% | 2020-05-19 | 2020-06-04 | 15d | 1399/02/30 | 1399/03/15 |

| ID | WBS | Task | Duration | Start | Finish | Predecessors | Complete | Remaining | Baseline start | Baseline finish | Baseline duration | Total slack | Free slack | شروع | پایان |
| --- | --- | --- | --- | --- | --- | --- | --- | --- | --- | --- | --- | --- | --- | --- | --- |
| 86 | 1.6.1.5 | **ساخت و مونتاژ** | 62d | 2020-06-16 A | 2020-08-26 A |  | 100% |  | 2020-06-16 | 2020-08-26 | 62d |  |  | 1399/03/27 | 1399/06/05 |
| 87 | 1.6.1.5.1 | مونتاژ ماژولهای قدرت | 3d | 2020-06-23 A | 2020-06-25 A | 77, 78, 80, 81 | 100% |  | 2020-06-23 | 2020-06-25 | 3d |  |  | 1399/04/03 | 1399/04/05 |
| 88 | 1.6.1.5.2 | مونتاژ بردهای الکترونیک | 3d | 2020-06-16 A | 2020-06-18 A | 79, 85 | 100% |  | 2020-06-16 | 2020-06-18 | 3d |  |  | 1399/03/27 | 1399/03/29 |
| 89 | 1.6.1.5.3 | جانمایی قطعات الکترونیکی و مکانیکی | 3d | 2020-08-20 A | 2020-08-23 A | 87, 82, 83, 84, 93 | 100% |  | 2020-08-20 | 2020-08-23 | 3d |  |  | 1399/05/30 | 1399/06/02 |
| 90 | 1.6.1.5.4 | سیم کشی و کابل کشی | 3d | 2020-08-24 A | 2020-08-26 A | 89 | 100% |  | 2020-08-24 | 2020-08-26 | 3d |  |  | 1399/06/03 | 1399/06/05 |
| 91 | 1.6.1.6 | **تست در کارخانه** | 77d | 2020-06-20 A | 2020-09-16 A |  | 100% |  | 2020-06-20 | 2020-09-16 | 77d |  |  | 1399/03/31 | 1399/06/26 |
| 92 | 1.6.1.6.1 | تست ظاهری | 3d | 2020-08-27 A | 2020-08-30 A | 90 | 100% |  | 2020-08-27 | 2020-08-30 | 3d |  |  | 1399/06/06 | 1399/06/09 |
| 93 | 1.6.1.6.2 | تست بردهای الکترونیک | 10d | 2020-06-20 A | 2020-06-30 A | 88 | 100% |  | 2020-06-20 | 2020-06-30 | 10d |  |  | 1399/03/31 | 1399/04/10 |
| 94 | 1.6.1.6.3 | راه اندازی اولیه | 3d | 2020-08-31 A | 2020-09-02 A | 93, 92 | 100% |  | 2020-08-31 | 2020-09-02 | 3d |  |  | 1399/06/10 | 1399/06/12 |
| 95 | 1.6.1.6.4 | تست مدت دار | 3d | 2020-09-03 A | 2020-09-06 A | 94 | 100% |  | 2020-09-03 | 2020-09-06 | 3d |  |  | 1399/06/13 | 1399/06/16 |
| 96 | 1.6.1.6.5 | انجام تست های استاندارد | 3d | 2020-09-07 A | 2020-09-09 A | 95 | 100% |  | 2020-09-07 | 2020-09-09 | 3d |  |  | 1399/06/17 | 1399/06/19 |
| 97 | 1.6.1.6.6 | بازرسی شخص ثالث | 3d | 2020-09-10 A | 2020-09-13 A | 96 | 100% |  | 2020-09-10 | 2020-09-13 | 3d |  |  | 1399/06/20 | 1399/06/23 |
| 98 | 1.6.1.6.7 | تائید بازرس شخص ثالث و مشاور | 3d | 2020-09-14 A | 2020-09-16 A | 97 | 100% |  | 2020-09-14 | 2020-09-16 | 3d |  |  | 1399/06/24 | 1399/06/26 |
| 99 | 1.6.1.7 | بسته بندی و تحویل | 6d | 2020-09-17 A | 2020-09-23 A | 98 | 100% |  | 2020-09-17 | 2020-09-23 | 6d |  |  | 1399/06/27 | 1399/07/02 |
| 100 | 1.6.1.8 | **تست در قطار** | 346d | 2020-09-24 A | 2021-11-01 |  | 86% | 48.04d | 2020-09-24 | 2021-11-01 | 346d | 0d |  | 1399/07/03 | 1400/08/10 |
| 101 | 1.6.1.8.1 | نصب تجهیز در واگن | 7d | 2020-09-24 A | 2020-10-01 A | 99 | 100% |  | 2020-09-24 | 2020-10-01 | 7d |  |  | 1399/07/03 | 1399/07/10 |
| 102 | 1.6.1.8.2 | انجام تست های استاتیک و دینامیک | 18d | 2020-10-03 A | 2021-08-24 | 101, 3 | 90% | 1.8d | 2020-10-03 | 2021-07-25 | 18d | 44.2d | 0d | 1399/07/12 | 1400/06/02 |
| 103 | 1.6.1.8.3 | اقدام اصلاحی | 90d | 2020-10-24 A | 2021-10-25 | 102 | 90% | 9d | 2020-10-24 | 2021-10-25 | 90d | 0d |  | 1399/08/03 | 1400/08/03 |
| 104 | 1.6.1.8.4 | تائید بازرس شخص ثالث و مشاور | 6d | 2021-10-26 | 2021-11-01 | 103 |  |  | 2021-10-26 | 2021-11-01 | 6d | 0d |  | 1400/08/04 | 1400/08/10 |
| 105 | 1.6.1.9 | **مستندات و مدارک فنی** | 387d | 2020-11-14 A | 2022-02-07 |  | 68% | 123.43d | 2020-11-14 | 2022-02-07 | 387d | 57d |  | 1399/08/24 | 1400/11/18 |
| 106 | 1.6.1.9.1 | MCM Product Description(3EST000209-8001) | 170d | 2020-11-14 A | 2022-02-06 | 104 | 80% | 34d | 2020-11-14 | 2022-02-06 | 170d | 58.6d |  | 1399/08/24 | 1400/11/17 |
| 107 | 1.6.1.9.2 | MCM Maintenance Instruction (3EST000209-8001) | 170d | 2020-11-14 A | 2022-02-06 | 104 | 80% | 34d | 2020-11-14 | 2022-02-06 | 170d | 58.6d |  | 1399/08/24 | 1400/11/17 |
| 108 | 1.6.1.9.3 | MCM Fan Maintenance Instruction (6489 004-15) | 170d | 2020-11-14 A | 2022-02-06 | 104 | 80% | 34d | 2020-11-14 | 2022-02-06 | 170d | 58.6d |  | 1399/08/24 | 1400/11/17 |
| 109 | 1.6.1.9.4 | DCU Maintenance Instruction (3EST 125-975, 3EST 125-977) | 168d | 2020-11-14 A | 2022-02-07 | 104 | 50% | 84d | 2020-11-14 | 2022-02-07 | 168d | 57d |  | 1399/08/24 | 1400/11/18 |
| 110 | 1.6.1.9.5 | Instruction manual, MCM inductor | 171d | 2020-11-14 A | 2022-02-07 | 104 | 80% | 34.2d | 2020-11-14 | 2022-02-07 | 171d | 57.6d |  | 1399/08/24 | 1400/11/18 |
| 111 | 1.6.1.9.6 | Maintenance, Overhaul & Repair instruction | 171d | 2020-11-14 A | 2022-02-07 | 104 | 80% | 34.2d | 2020-11-14 | 2022-02-07 | 171d | 57.6d |  | 1399/08/24 | 1400/11/18 |
| 112 | 1.6.1.9.7 | MCM: Outline drawing | 171d | 2020-11-14 A | 2022-02-07 | 104 | 80% | 34.2d | 2020-11-14 | 2022-02-07 | 171d | 57.6d |  | 1399/08/24 | 1400/11/18 |
| 113 | 1.6.1.9.8 | MCM: Assembly drawing | 168d | 2020-11-14 A | 2022-02-07 | 104 | 50% | 84d | 2020-11-14 | 2022-02-07 | 168d | 57d |  | 1399/08/24 | 1400/11/18 |
| 114 | 1.6.1.9.9 | MCM: Circuit diagram, DMA 0804E | 168d | 2020-11-14 A | 2022-02-07 | 104 | 50% | 84d | 2020-11-14 | 2022-02-07 | 168d | 57d |  | 1399/08/24 | 1400/11/18 |
| 115 | 1.6.1.9.10 | ACM (3EST000209-8010) | 168d | 2020-11-14 A | 2022-02-07 | 104 | 50% | 84d | 2020-11-14 | 2022-02-07 | 168d | 57d |  | 1399/08/24 | 1400/11/18 |

| ID | WBS | Task | Duration | Start | Finish | Predecessors | Complete | Remaining | Baseline start | Baseline finish | Baseline duration | Total slack | شروع | پایان |
| --- | --- | --- | --- | --- | --- | --- | --- | --- | --- | --- | --- | --- | --- | --- |
| 116 | 1.6.2 | **HV Boxs** | 642d | 2020-01-21 A | 2022-02-07 |  | 93% | 42.21d | 2020-01-21 | 2022-02-07 | 642d | 57d | 1398/11/01 | 1400/11/18 |
| 117 | 1.6.2.1 | **طراحی پایه و تفصیلی** | 15d | 2020-01-21 A | 2020-02-06 A |  | 100% |  | 2020-01-21 | 2020-02-06 | 15d |  | 1398/11/01 | 1398/11/17 |
| 118 | 1.6.2.1.1 | طراحی مکانیکال | 6d | 2020-01-21 A | 2020-01-27 A | 22 | 100% |  | 2020-01-21 | 2020-01-27 | 6d |  | 1398/11/01 | 1398/11/07 |
| 119 | 1.6.2.1.2 | طراحی الکتریکال | 6d | 2020-01-21 A | 2020-01-27 A | 118SS | 100% |  | 2020-01-21 | 2020-01-27 | 6d |  | 1398/11/01 | 1398/11/07 |
| 120 | 1.6.2.1.3 | طراحی جانمایی | 5d | 2020-01-21 A | 2020-01-26 A | 119SS | 100% |  | 2020-01-21 | 2020-01-26 | 5d |  | 1398/11/01 | 1398/11/06 |
| 121 | 1.6.2.1.4 | دریافت تاییدیه از مشاور | 10d | 2020-01-27 A | 2020-02-06 A | 120 | 100% |  | 2020-01-27 | 2020-02-06 | 10d |  | 1398/11/07 | 1398/11/17 |
| 122 | 1.6.2.2 | **تامین و تدارکات** | 22d | 2020-02-08 A | 2020-03-03 A |  | 100% |  | 2020-02-08 | 2020-03-03 | 22d |  | 1398/11/19 | 1398/12/13 |
| 123 | 1.6.2.2.1 | شناسایی تامین کنندگان/انتخاب پیمانکار داخلی یا خارجی | 3d | 2020-02-08 A | 2020-02-10 A | 121 | 100% |  | 2020-02-08 | 2020-02-10 | 3d |  | 1398/11/19 | 1398/11/21 |
| 124 | 1.6.2.2.2 | بدنه | 5d | 2020-02-11 A | 2020-02-16 A | 123 | 100% |  | 2020-02-11 | 2020-02-16 | 5d |  | 1398/11/22 | 1398/11/27 |
| 125 | 1.6.2.2.3 | قطعات الکترونیک و الکترونیک قدرت | 12d | 2020-02-11 A | 2020-02-24 A | 123 | 100% |  | 2020-02-11 | 2020-02-24 | 12d |  | 1398/11/22 | 1398/12/05 |
| 126 | 1.6.2.2.4 | سیم و کابل | 6d | 2020-02-11 A | 2020-02-17 A | 123 | 100% |  | 2020-02-11 | 2020-02-17 | 6d |  | 1398/11/22 | 1398/11/28 |
| 127 | 1.6.2.2.5 | انواع کانکتورها | 5d | 2020-02-11 A | 2020-02-16 A | 123 | 100% |  | 2020-02-11 | 2020-02-16 | 5d |  | 1398/11/22 | 1398/11/27 |
| 128 | 1.6.2.2.6 | HSCB | 19d | 2020-02-11 A | 2020-03-03 A | 123 | 100% |  | 2020-02-11 | 2020-03-03 | 19d |  | 1398/11/22 | 1398/12/13 |
| 129 | 1.6.2.3 | **ساخت و مونتاژ** | 12d | 2020-03-04 A | 2020-03-17 A |  | 100% |  | 2020-03-04 | 2020-03-17 | 12d |  | 1398/12/14 | 1398/12/27 |
| 130 | 1.6.2.3.1 | جانمایی قطعات الکترونیکی و مکانیکی | 6d | 2020-03-04 A | 2020-03-10 A | 128 | 100% |  | 2020-03-04 | 2020-03-10 | 6d |  | 1398/12/14 | 1398/12/20 |
| 131 | 1.6.2.3.2 | سیم کشی و کابل کشی | 6d | 2020-03-11 A | 2020-03-17 A | 130 | 100% |  | 2020-03-11 | 2020-03-17 | 6d |  | 1398/12/21 | 1398/12/27 |
| 132 | 1.6.2.4 | **تست در کارخانه** | 35d | 2020-03-18 A | 2020-04-27 A |  | 100% |  | 2020-03-18 | 2020-04-27 | 35d |  | 1398/12/28 | 1399/02/08 |
| 133 | 1.6.2.4.1 | تست ظاهری | 5d | 2020-03-18 A | 2020-03-23 A | 131 | 100% |  | 2020-03-18 | 2020-03-23 | 5d |  | 1398/12/28 | 1399/01/04 |
| 134 | 1.6.2.4.2 | راه اندازی اولیه | 5d | 2020-03-24 A | 2020-03-29 A | 133 | 100% |  | 2020-03-24 | 2020-03-29 | 5d |  | 1399/01/05 | 1399/01/10 |
| 135 | 1.6.2.4.3 | تست مدت دار | 5d | 2020-03-30 A | 2020-04-04 A | 134 | 100% |  | 2020-03-30 | 2020-04-04 | 5d |  | 1399/01/11 | 1399/01/16 |
| 136 | 1.6.2.4.4 | انجام تست های استاندارد | 5d | 2020-04-05 A | 2020-04-09 A | 135 | 100% |  | 2020-04-05 | 2020-04-09 | 5d |  | 1399/01/17 | 1399/01/21 |
| 137 | 1.6.2.4.5 | بازرسی شخص ثالث | 5d | 2020-04-11 A | 2020-04-15 A | 136 | 100% |  | 2020-04-11 | 2020-04-15 | 5d |  | 1399/01/23 | 1399/01/27 |
| 138 | 1.6.2.4.6 | تائید بازرس شخص ثالث و مشاور | 10d | 2020-04-16 A | 2020-04-27 A | 137 | 100% |  | 2020-04-16 | 2020-04-27 | 10d |  | 1399/01/28 | 1399/02/08 |
| 139 | 1.6.2.5 | بسته بندی و تحویل | 5d | 2020-04-28 A | 2020-05-03 A | 138 | 100% |  | 2020-04-28 | 2020-05-03 | 5d |  | 1399/02/09 | 1399/02/14 |

| ID | WBS | Task | Duration | Start | Finish | Predecessors | Complete | Remaining | Baseline start | Baseline finish | Baseline duration | Total slack | شروع | پایان |
| --- | --- | --- | --- | --- | --- | --- | --- | --- | --- | --- | --- | --- | --- | --- |
| 140 | 1.6.2.6 | **تست در قطار** | 504d | 2020-05-04 A | 2021-12-12 |  | 28% | 363.79d | 2020-05-04 | 2021-11-11 | 478d | 106d | 1399/02/15 | 1400/09/21 |
| 141 | 1.6.2.6.1 | نصب تجهیز در واگن | 7d | 2020-05-04 A | 2020-05-11 A | 139 | 100% |  | 2020-05-04 | 2020-05-11 | 7d |  | 1399/02/15 | 1399/02/22 |
| 142 | 1.6.2.6.2 | انجام تست های استاتیک و دینامیک | 18d | 2020-10-03 A | 2020-10-22 A | 141, 102SS | 100% |  | 2020-10-03 | 2020-10-22 | 18d |  | 1399/07/12 | 1399/08/01 |
| 143 | 1.6.2.6.3 | اقدام اصلاحی | 12d | 2020-10-24 A | 2020-11-05 A | 142 | 100% |  | 2020-10-24 | 2020-11-05 | 12d |  | 1399/08/03 | 1399/08/15 |
| 144 | 1.6.2.6.4 | تائید بازرس شخص ثالث و مشاور | 96d | 2021-08-23 | 2021-12-12 | 143, 4 |  |  | 2021-07-24 | 2021-11-11 | 96d | 106d | 1400/06/01 | 1400/09/21 |
| 145 | 1.6.2.7 | **مستندات و مدارک فنی** | 269d | 2021-03-31 A | 2022-02-07 A |  | 100% |  | 2021-03-31 | 2022-02-07 | 269d |  | 1400/01/11 | 1400/11/18 |
| 146 | 1.6.2.7.1 | HV-box MCM-Cab: Circuit Diagram | 152d | 2021-03-31 A | 2022-02-07 A | 144, 164, 177, 195, 231 | 100% |  | 2021-03-31 | 2022-02-07 | 152d |  | 1400/01/11 | 1400/11/18 |
| 147 | 1.6.2.7.2 | HV-box MCM & MCM-Cab: Outline Drawing | 152d | 2021-03-31 A | 2022-02-07 A | 144, 164, 177, 195, 231 | 100% |  | 2021-03-31 | 2022-02-07 | 152d |  | 1400/01/11 | 1400/11/18 |
| 148 | 1.6.2.7.3 | HV-box MCM: Assembly Drawing | 149d | 2021-03-31 A | 2022-02-07 A | 144, 164, 177, 195, 231 | 100% |  | 2021-03-31 | 2022-02-07 | 149d |  | 1400/01/11 | 1400/11/18 |
| 149 | 1.6.2.7.4 | HV-box MCM-Cab: Assembly Drawing | 149d | 2021-03-31 A | 2022-02-07 A | 144, 164, 177, 195, 231 | 100% |  | 2021-03-31 | 2022-02-07 | 149d |  | 1400/01/11 | 1400/11/18 |
| 150 | 1.6.2.7.5 | HV-box ACM: Outline Drawing | 149d | 2021-03-31 A | 2022-02-07 A | 144, 164, 177, 195, 231 | 100% |  | 2021-03-31 | 2022-02-07 | 149d |  | 1400/01/11 | 1400/11/18 |
| 151 | 1.6.2.7.6 | HV-box ACM: Assembly Drawing | 149d | 2021-03-31 A | 2022-02-07 A | 144, 164, 177, 195, 231 | 100% |  | 2021-03-31 | 2022-02-07 | 149d |  | 1400/01/11 | 1400/11/18 |
| 152 | 1.6.2.7.7 | HV Line Circuit Breaker: Assembly drawing | 149d | 2021-03-31 A | 2022-02-07 A | 144, 164, 177, 195, 231 | 100% |  | 2021-03-31 | 2022-02-07 | 149d |  | 1400/01/11 | 1400/11/18 |
| 153 | 1.6.2.7.8 | HV Line Circuit Breaker: Circuit Drawing | 149d | 2021-03-31 A | 2022-02-07 A | 144, 164, 177, 195, 231 | 100% |  | 2021-03-31 | 2022-02-07 | 149d |  | 1400/01/11 | 1400/11/18 |
| 154 | 1.6.3 | **DBR** | 641.5d | 2020-01-21 A | 2022-02-07 |  | 99% | 6.27d | 2020-01-21 | 2022-02-07 | 641.5d | 57.5d | 1398/11/01 | 1400/11/18 |
| 155 | 1.6.3.1 | تدوین RFP | 5d | 2020-01-21 A | 2020-01-26 A | 22 | 100% |  | 2020-01-21 | 2020-01-26 | 5d |  | 1398/11/01 | 1398/11/06 |
| 156 | 1.6.3.2 | شناسایی تامین کنندگان | 6d | 2020-01-27 A | 2020-02-02 A | 155 | 100% |  | 2020-01-27 | 2020-02-02 | 6d |  | 1398/11/07 | 1398/11/13 |
| 157 | 1.6.3.3 | سفارش و ساخت | 40d | 2020-02-03 A | 2020-03-19 A | 156 | 100% |  | 2020-02-03 | 2020-03-19 | 40d |  | 1398/11/14 | 1398/12/29 |
| 158 | 1.6.3.4 | تست در کارخانه | 33d | 2020-03-21 A | 2020-04-27 A | 157 | 100% |  | 2020-03-21 | 2020-04-27 | 33d |  | 1399/01/02 | 1399/02/08 |
| 159 | 1.6.3.5 | بسته بندی | 5d | 2020-04-28 A | 2020-05-03 A | 158 | 100% |  | 2020-04-28 | 2020-05-03 | 5d |  | 1399/02/09 | 1399/02/14 |
| 160 | 1.6.3.6 | **تست در قطار** | 411d | 2020-05-04 A | 2021-08-25 |  | 93% | 28.67d | 2020-05-04 | 2021-07-26 | 385d | 199d | 1399/02/15 | 1400/06/03 |
| 161 | 1.6.3.6.1 | نصب تجهیز در واگن | 7d | 2020-05-04 A | 2020-05-11 A | 159 | 100% |  | 2020-05-04 | 2020-05-11 | 7d |  | 1399/02/15 | 1399/02/22 |
| 162 | 1.6.3.6.2 | انجام تست های استاتیک و دینامیک | 18d | 2020-10-03 A | 2020-10-22 A | 161, 102SS | 100% |  | 2020-10-03 | 2020-10-22 | 18d |  | 1399/07/12 | 1399/08/01 |
| 163 | 1.6.3.6.3 | اقدام اصلاحی | 12d | 2020-10-24 A | 2020-11-05 A | 162 | 100% |  | 2020-10-24 | 2020-11-05 | 12d |  | 1399/08/03 | 1399/08/15 |
| 164 | 1.6.3.6.4 | تائید بازرس شخص ثالث و مشاور | 6d | 2020-11-07 A | 2021-08-25 | 163, 4 | 50% | 3d | 2020-11-07 | 2021-07-26 | 6d | 199d | 1399/08/17 | 1400/06/03 |

| ID | WBS | Task | Type | Duration | Start | Finish | Predecessors | Complete | Remaining | Baseline start | Baseline finish | Baseline duration | Total slack | شروع | پایان |
| --- | --- | --- | --- | --- | --- | --- | --- | --- | --- | --- | --- | --- | --- | --- | --- |
| 165 | 1.6.3.7 | **مستندات و مدارک فنی** |  | 218.5d | 2021-05-29 A | 2022-02-07 A |  | 100% |  | 2021-05-29 | 2022-02-07 | 218.5d |  | 1400/03/08 | 1400/11/18 |
| 166 | 1.6.3.7.1 | Test and Commissioning Procedure | manual | 175d | 2021-05-29 A | 2022-02-07 A | 160, 173, 191, 3 | 100% |  | 2021-05-29 | 2022-02-07 | 175d |  | 1400/03/08 | 1400/11/18 |
| 167 | 1.6.4 | **Traction Motor** |  | 642d | 2020-01-21 A | 2022-02-07 |  | 98% | 9.79d | 2020-01-21 | 2022-02-07 | 642d | 57d | 1398/11/01 | 1400/11/18 |
| 168 | 1.6.4.1 | تدوین RFP |  | 5d | 2020-01-21 A | 2020-01-26 A | 22 | 100% |  | 2020-01-21 | 2020-01-26 | 5d |  | 1398/11/01 | 1398/11/06 |
| 169 | 1.6.4.2 | شناسایی تامین کنندگان |  | 10d | 2020-01-27 A | 2020-02-06 A | 168 | 100% |  | 2020-01-27 | 2020-02-06 | 10d |  | 1398/11/07 | 1398/11/17 |
| 170 | 1.6.4.3 | سفارش و ساخت |  | 120d | 2020-02-08 A | 2020-06-25 A | 169 | 100% |  | 2020-02-08 | 2020-06-25 | 120d |  | 1398/11/19 | 1399/04/05 |
| 171 | 1.6.4.4 | تست در کارخانه |  | 65d | 2020-06-27 A | 2020-09-09 A | 170 | 100% |  | 2020-06-27 | 2020-09-09 | 65d |  | 1399/04/07 | 1399/06/19 |
| 172 | 1.6.4.5 | بسته بندی |  | 10d | 2020-09-10 A | 2020-09-21 A | 171 | 100% |  | 2020-09-10 | 2020-09-21 | 10d |  | 1399/06/20 | 1399/06/31 |
| 173 | 1.6.4.6 | **تست در قطار** |  | 303.5d | 2020-09-22 A | 2021-09-11 |  | 62% | 116.46d | 2020-09-22 | 2021-08-11 | 277.5d | 185.5d | 1399/07/01 | 1400/06/20 |
| 174 | 1.6.4.6.1 | نصب تجهیز در واگن |  | 7d | 2020-09-22 A | 2021-08-25 | 172, 3 | 70% | 2.1d | 2020-09-22 | 2021-07-26 | 7d | 0d | 1399/07/01 | 1400/06/03 |
| 175 | 1.6.4.6.2 | انجام تست های استاتیک و دینامیک |  | 18d | 2020-10-03 A | 2021-08-31 | 174, 102SS | 70% | 5.4d | 2020-10-03 | 2021-08-01 | 18d | 0d | 1399/07/12 | 1400/06/09 |
| 176 | 1.6.4.6.3 | اقدام اصلاحی |  | 12d | 2020-10-24 A | 2021-09-07 | 175 | 50% | 6d | 2020-10-24 | 2021-08-08 | 12d | 0d | 1399/08/03 | 1400/06/16 |
| 177 | 1.6.4.6.4 | تائید بازرس شخص ثالث و مشاور |  | 6d | 2020-11-07 A | 2021-09-11 | 176 | 50% | 3d | 2020-11-07 | 2021-08-11 | 6d | 185.5d | 1399/08/17 | 1400/06/20 |
| 178 | 1.6.4.7 | **مستندات و مدارک فنی** |  | 380d | 2020-11-22 A | 2022-02-07 A |  | 100% |  | 2020-11-22 | 2022-02-07 | 380d |  | 1399/09/02 | 1400/11/18 |
| 179 | 1.6.4.7.1 | Outline Drawing of Traction Motor |  | 162d | 2020-11-22 A | 2022-02-07 A | 173, 191 | 100% |  | 2020-11-22 | 2022-02-07 | 162d |  | 1399/09/02 | 1400/11/18 |
| 180 | 1.6.4.7.2 | Bill of Material (BOM) |  | 15d | 2020-11-22 A | 2020-12-08 A | 173, 191 | 100% |  | 2020-11-22 | 2020-12-08 | 15d |  | 1399/09/02 | 1399/09/18 |
| 181 | 1.6.4.7.3 | Traction Motor Illustrated parts catalog |  | 166d | 2020-11-22 A | 2022-02-07 A | 173, 191 | 100% |  | 2020-11-22 | 2022-02-07 | 166d |  | 1399/09/02 | 1400/11/18 |
| 182 | 1.6.4.7.4 | Maintenance Manual |  | 162d | 2020-11-22 A | 2022-02-07 A | 173, 191 | 100% |  | 2020-11-22 | 2022-02-07 | 162d |  | 1399/09/02 | 1400/11/18 |
| 183 | 1.6.4.7.5 | Shock and Vibration Simulation Analysis |  | 162d | 2020-11-22 A | 2022-02-07 A | 173, 191 | 100% |  | 2020-11-22 | 2022-02-07 | 162d |  | 1399/09/02 | 1400/11/18 |
| 184 | 1.6.4.7.6 | Specification for Traction motor |  | 162d | 2020-11-22 A | 2022-02-07 A | 173, 191 | 100% |  | 2020-11-22 | 2022-02-07 | 162d |  | 1399/09/02 | 1400/11/18 |
| 185 | 1.6.5 | **Gearbox** |  | 699d | 2020-01-21 A | 2022-04-14 |  | 92% | 56.99d | 2020-01-21 | 2022-02-07 | 641.6d | 0d | 1398/11/01 | 1401/01/25 |
| 186 | 1.6.5.1 | تدوین RFP |  | 5d | 2020-01-21 A | 2020-01-26 A | 22 | 100% |  | 2020-01-21 | 2020-01-26 | 5d |  | 1398/11/01 | 1398/11/06 |
| 187 | 1.6.5.2 | شناسایی تامین کنندگان |  | 10d | 2020-01-27 A | 2020-02-06 A | 186 | 100% |  | 2020-01-27 | 2020-02-06 | 10d |  | 1398/11/07 | 1398/11/17 |
| 188 | 1.6.5.3 | سفارش و ساخت |  | 120d | 2020-02-08 A | 2020-06-25 A | 187 | 100% |  | 2020-02-08 | 2020-06-25 | 120d |  | 1398/11/19 | 1399/04/05 |
| 189 | 1.6.5.4 | تست در کارخانه |  | 65d | 2020-06-27 A | 2020-09-09 A | 188 | 100% |  | 2020-06-27 | 2020-09-09 | 65d |  | 1399/04/07 | 1399/06/19 |
| 190 | 1.6.5.5 | بسته بندی |  | 10d | 2020-09-10 A | 2020-09-21 A | 189 | 100% |  | 2020-09-10 | 2020-09-21 | 10d |  | 1399/06/20 | 1399/06/31 |

| ID | WBS | Task | Duration | Start | Finish | Predecessors | Complete | Remaining | Baseline start | Baseline finish | Baseline duration | Total slack | Free slack | شروع | پایان |
| --- | --- | --- | --- | --- | --- | --- | --- | --- | --- | --- | --- | --- | --- | --- | --- |
| 191 | 1.6.5.6 | **تست در قطار** | 334.1d | 2020-10-03 A | 2021-10-27 | 190, 102SS | 57% | 144.78d | 2020-10-03 | 2021-10-27 | 334.1d | 145.9d |  | 1399/07/12 | 1400/08/05 |
| 192 | 1.6.5.6.1 | نصب تجهیز در واگن | 7d | 2020-10-03 A | 2021-08-25 | 190, 3 | 70% | 2.1d | 2020-10-03 | 2021-07-26 | 7d | 0d |  | 1399/07/12 | 1400/06/03 |
| 193 | 1.6.5.6.2 | انجام تست های استاتیک و دینامیک | 18d | 2020-10-11 A | 2021-08-31 | 192, 102SS | 70% | 5.4d | 2020-10-11 | 2021-08-01 | 18d | 0d |  | 1399/07/20 | 1400/06/09 |
| 194 | 1.6.5.6.3 | اقدام اصلاحی | 12d | 2020-11-01 A | 2021-09-05 | 193 | 70% | 3.6d | 2020-11-01 | 2021-08-05 | 12d | 8d | 0d | 1399/08/11 | 1400/06/14 |
| 195 | 1.6.5.6.4 | تائید بازرس شخص ثالث و مشاور | 74d | 2020-11-15 A | 2021-10-27 | 194 | 50% | 37d | 2020-11-15 | 2021-10-27 | 74d | 145.9d |  | 1399/08/25 | 1400/08/05 |
| 196 | 1.6.5.7 | **مستندات و مدارک فنی** | 437d | 2020-11-22 A | 2022-04-14 A |  | 100% |  | 2020-11-22 | 2022-02-07 | 379.6d |  |  | 1399/09/02 | 1401/01/25 |
| 197 | 1.6.5.7.1 | Assembly instructions | 15d | 2020-11-22 A | 2020-12-08 A | 191 | 100% |  | 2020-11-22 | 2020-12-08 | 15d |  |  | 1399/09/02 | 1399/09/18 |
| 198 | 1.6.5.7.2 | Bearing specification and calculation | 15d | 2020-11-22 A | 2020-12-08 A | 191 | 100% |  | 2020-11-22 | 2020-12-08 | 15d |  |  | 1399/09/02 | 1399/09/18 |
| 199 | 1.6.5.7.3 | Casting specification report | 164d | 2020-11-22 A | 2022-02-07 A | 191 | 100% |  | 2020-11-22 | 2022-02-07 | 164d |  |  | 1399/09/02 | 1400/11/18 |
| 200 | 1.6.5.7.4 | Coupling outline drawing | 15d | 2020-11-22 A | 2020-12-08 A | 191 | 100% |  | 2020-11-22 | 2020-12-08 | 15d |  |  | 1399/09/02 | 1399/09/18 |
| 201 | 1.6.5.7.5 | Gearbox & Coupling installation instructions | 60d | 2021-06-15 A | 2022-04-14 A | 271SS | 100% |  | 2021-06-15 | 2022-04-14 | 60d |  |  | 1400/03/25 | 1401/01/25 |
| 202 | 1.6.6 | **TCMS** | 646d | 2020-01-21 A | 2022-02-12 |  | 89% | 74.04d | 2020-01-21 | 2022-02-07 | 642d | 53d |  | 1398/11/01 | 1400/11/23 |
| 203 | 1.6.6.1 | **طراحی لاجیک، مستندات و مدارک فنی** | 646d | 2020-01-21 A | 2022-02-12 |  | 94% | 41.83d | 2020-01-21 | 2022-02-07 | 642d | 53d |  | 1398/11/01 | 1400/11/23 |
| 204 | 1.6.6.1.1 | VCU (3EST 92-488) & MOBAD (3EST 92-492) | 20d | 2020-01-21 A | 2021-08-26 A | 22, 3 | 100% |  | 2020-01-21 | 2020-02-12 | 20d |  |  | 1398/11/01 | 1400/06/04 |
| 205 | 1.6.6.1.2 | Digital input/output unit (DX, 3EST 13-149) | 187d | 2020-02-13 A | 2022-02-07 A | 204, 3 | 100% |  | 2020-02-13 | 2022-02-07 | 187d |  |  | 1398/11/24 | 1400/11/18 |
| 206 | 1.6.6.1.3 | Digital input unit (DI, 3EST 13-467) | 20d | 2020-03-08 A | 2022-02-12 A | 205 | 100% |  | 2020-03-08 | 2020-03-30 | 20d |  |  | 1398/12/18 | 1400/11/23 |
| 207 | 1.6.6.1.4 | Test Specification, TCMS standstill tests | 20d | 2020-04-23 A | 2020-05-16 A |  | 100% |  | 2020-04-23 | 2020-05-16 | 20d |  |  | 1399/02/04 | 1399/02/27 |
| 208 | 1.6.6.1.5 | Software Design Description, High Voltage | 20d | 2020-05-17 A | 2020-06-08 A | 207 | 100% |  | 2020-05-17 | 2020-06-08 | 20d |  |  | 1399/02/28 | 1399/03/19 |
| 209 | 1.6.6.1.6 | Software Design Description, Train operation | 20d | 2020-06-09 A | 2020-07-01 A | 208 | 100% |  | 2020-06-09 | 2020-07-01 | 20d |  |  | 1399/03/20 | 1399/04/11 |
| 210 | 1.6.6.1.7 | Software Design Description, Propulsion | 20d | 2020-07-02 A | 2020-07-25 | 209 | 80% | 4d | 2020-07-02 | 2020-07-25 | 20d | 16d | 0d | 1399/04/12 | 1399/05/04 |
| 211 | 1.6.6.1.8 | Software Design Description, Information | 20d | 2020-07-26 A | 2020-08-17 | 210 | 80% | 4d | 2020-07-26 | 2020-08-17 | 20d | 519d |  | 1399/05/05 | 1399/05/27 |
| 212 | 1.6.6.1.9 | Software Design Description, Train Diag System | 20d | 2020-08-18 A | 2021-08-26 A | 211, 3 | 100% |  | 2020-08-18 | 2021-08-03 | 20d |  |  | 1399/05/28 | 1400/06/04 |
| 213 | 1.6.6.1.10 | Software Design Description, TDS Picture Model | 171d | 2020-09-10 A | 2022-02-07 | 212 | 80% | 34.2d | 2020-09-10 | 2022-02-07 | 171d | 57d |  | 1399/06/20 | 1400/11/18 |
| 214 | 1.6.6.1.11 | Software Design Description, Brake | 20d | 2020-01-21 A | 2021-08-26 A | 22, 3 | 100% |  | 2020-01-21 | 2021-08-03 | 20d |  |  | 1398/11/01 | 1400/06/04 |
| 215 | 1.6.6.1.12 | Software Design Description, Battery | 20d | 2020-02-13 A | 2021-08-31 A | 214 | 100% |  | 2020-02-13 | 2021-08-15 | 20d |  |  | 1398/11/24 | 1400/06/09 |
| 216 | 1.6.6.1.13 | Software Design Description, Doors | 20d | 2020-03-08 A | 2021-09-05 A | 215 | 100% |  | 2020-03-08 | 2021-08-19 | 20d |  |  | 1398/12/18 | 1400/06/14 |
| 217 | 1.6.6.1.14 | Software Design Description, HVAC | 20d | 2020-03-31 A | 2021-09-09 A | 216 | 100% |  | 2020-03-31 | 2021-08-24 | 20d |  |  | 1399/01/12 | 1400/06/18 |
| 218 | 1.6.6.1.15 | Software Design Description, Comp & Comm | 20d | 2020-04-23 A | 2021-09-14 A | 217 | 100% |  | 2020-04-23 | 2021-09-05 | 20d |  |  | 1399/02/04 | 1400/06/23 |
| 219 | 1.6.6.1.16 | Software Design Description, MCM | 20d | 2020-05-17 A | 2021-09-19 | 218 | 80% | 4d | 2020-05-17 | 2021-09-09 | 20d | 0d |  | 1399/02/28 | 1400/06/28 |
| 220 | 1.6.6.1.17 | Software Design Description, ACM | 20d | 2020-06-09 A | 2021-09-23 | 219 | 80% | 4d | 2020-06-09 | 2021-09-21 | 20d | 174d |  | 1399/03/20 | 1400/07/01 |
| 221 | 1.6.6.1.18 | I/O Signal List | 20d | 2020-07-02 A | 2021-10-03 A | 220 | 100% |  | 2020-07-02 | 2021-10-03 | 20d |  |  | 1399/04/12 | 1400/07/11 |
| 222 | 1.6.6.1.19 | Event Indication Signal Description | 20d | 2020-07-26 A | 2021-10-14 A | 221 | 100% |  | 2020-07-26 | 2021-10-14 | 20d |  |  | 1399/05/05 | 1400/07/22 |
| 223 | 1.6.6.1.20 | Software Diagram, VCU | 20d | 2020-08-18 A | 2021-10-26 | 222 | 80% | 4d | 2020-08-18 | 2021-10-26 | 20d | 146d |  | 1399/05/28 | 1400/08/04 |
| 224 | 1.6.6.1.21 | Removal & Replacement instrument, DCU | 99d | 2020-09-10 A | 2022-02-07 A | 223 | 100% |  | 2020-09-10 | 2022-02-07 | 99d |  |  | 1399/06/20 | 1400/11/18 |
| 225 | 1.6.6.1.22 | Preventive Maintenance Schedule | 20d | 2020-01-21 A | 2021-08-26 A | 22, 3 | 100% |  | 2020-01-21 | 2021-08-03 | 20d |  |  | 1398/11/01 | 1400/06/04 |
| 226 | 1.6.6.2 | بسته بندی و تحویل | 10d | 2022-01-26 A | 2022-02-06 A |  | 100% |  | 2022-01-26 | 2022-02-06 | 10d |  |  | 1400/11/06 | 1400/11/17 |

| ID | WBS | Task | Duration | Start | Finish | Predecessors | Complete | Remaining | Baseline start | Baseline finish | Baseline duration | Total slack | Free slack | Constraint | شروع | پایان |
| --- | --- | --- | --- | --- | --- | --- | --- | --- | --- | --- | --- | --- | --- | --- | --- | --- |
| 227 | 1.6.6.3 | **تست در قطار** | 175.5d | 2021-03-21 A | 2021-10-11 |  | 43% | 100.79d | 2021-03-21 | 2022-01-26 | 268d | 159.5d |  |  | 1400/01/01 | 1400/07/19 |
| 228 | 1.6.6.3.1 | نصب تجهیز در واگن | 7d | 2021-03-21 A | 2021-03-28 A |  | 100% |  | 2021-03-21 | 2021-03-28 | 7d |  |  | must start on 2021-03-21 | 1400/01/01 | 1400/01/08 |
| 229 | 1.6.6.3.2 | انجام تست های استاتیک و دینامیک | 49d | 2021-03-29 A | 2021-09-20 | 228, 102SS, 3 | 50% | 24.5d | 2021-03-29 | 2021-09-07 | 49d | 159.5d | 0d |  | 1400/01/09 | 1400/06/29 |
| 230 | 1.6.6.3.3 | اقدام اصلاحی | 12d | 2021-09-20 | 2021-10-04 | 229 |  |  | 2021-09-08 | 2021-09-21 | 12d | 159.5d | 0d |  | 1400/06/29 | 1400/07/12 |
| 231 | 1.6.6.3.4 | تائید بازرس شخص ثالث و مشاور | 6d | 2021-10-04 | 2021-10-11 | 230 |  |  | 2021-09-22 | 2021-09-28 | 6d | 159.5d |  |  | 1400/07/12 | 1400/07/19 |
| 232 | 1.6.6.4 | تائید مشاور | 10d | 2021-08-23 | 2021-09-02 | 4 |  |  | 2022-01-27 | 2022-02-07 | 10d | 192d |  |  | 1400/06/01 | 1400/06/11 |
| 233 | 1.7 | **طراحی اینترفیس های الکتریکی به زیرساخت ها** | 60d | 2020-04-08 A | 2020-06-16 A |  | 100% |  | 2020-03-31 | 2022-03-10 | 609d |  |  |  | 1399/01/20 | 1399/03/27 |
| 234 | 1.7.1 | Wiring Diagram (Main Circuit) | 60d | 2020-04-08 A | 2020-06-16 A | 37 | 100% |  | 2020-04-08 | 2020-04-13 | 5d |  |  |  | 1399/01/20 | 1399/03/27 |
| 235 | 1.8 | **طراحی اینترفیس های مکانیکی به زیرساخت ها** | 502d | 2020-01-21 A | 2021-08-28 |  | 85% | 77.5d | 2020-01-21 | 2021-09-07 | 510.2d | 197d |  |  | 1398/11/01 | 1400/06/06 |
| 236 | 1.8.1 | Propulsion Equipment | 10d | 2020-01-21 A | 2021-08-28 | 22, 3 | 50% | 5d | 2020-01-21 | 2021-07-28 | 10d | 197d |  |  | 1398/11/01 | 1400/06/06 |
| 237 | 1.8.2 | یکپارچه سازی و اتصال گیربکس، موتور و کوپلینگ به بوژی | 30d | 2020-04-05 A | 2020-05-09 |  | 92% | 2.4d | 2020-02-13 | 2021-08-21 | 30d | 605d |  |  | 1399/01/17 | 1399/02/20 |
| 238 | 1.8.3 | Drivers Desk I/O unit (DDIO, 3EST 92-329) | 7d | 2020-04-05 A | 2020-04-12 |  | 80% | 1.4d | 2020-04-05 | 2021-08-26 | 7d | 628d |  |  | 1399/01/17 | 1399/01/24 |
| 239 | 1.8.4 | TCMS Software & Hardware Architecture | 10d | 2020-04-13 A | 2020-04-23 A | 238 | 100% |  | 2020-04-13 | 2021-08-28 | 10d |  |  |  | 1399/01/25 | 1399/02/04 |
| 240 | 1.9 | **تدوین دستورالعمل‌های تعمیر و نگهداری سیستم رانش** | 546.2d | 2020-06-11 A | 2022-03-10 A |  | 100% |  | 2020-05-24 | 2022-03-10 | 562.2d |  |  |  | 1399/03/22 | 1400/12/19 |
| 241 | 1.9.1 | Maintenance Instruction of HV-BOX ACM | 15d | 2021-09-07 A | 2021-09-25 A |  | 100% |  | 2021-09-07 | 2021-09-25 | 15d |  |  |  | 1400/06/16 | 1400/07/03 |
| 242 | 1.9.2 | Maintenance Instruction of HVB MCM/MCM-Cab | 140d | 2020-06-11 A | 2022-03-10 A |  | 100% |  | 2020-06-11 | 2022-03-10 | 140d |  |  |  | 1399/03/22 | 1400/12/19 |
| 243 | 1.10 | **تدوین دستورالعمل‌های تست و راه‌اندازی سیستم رانش** | 903.2d | 2019-04-22 A | 2022-03-10 |  | 81% | 169.35d | 2020-06-10 | 2022-03-10 | 547.2d | 30.8d |  |  | 1398/02/02 | 1400/12/19 |
| 244 | 1.10.1 | تدوین دستورالعملهای تست روتین | 10d | 2019-04-22 | 2019-05-02 |  |  |  | 2021-09-07 | 2021-09-19 | 10d | 904d | 0d |  | 1398/02/02 | 1398/02/12 |
| 245 | 1.10.2 | تدوین دستورالعملهای تست تایپ | 10d | 2019-05-04 | 2019-05-14 | 244 |  |  | 2021-09-19 | 2021-09-30 | 10d | 904d | 0d |  | 1398/02/14 | 1398/02/24 |
| 246 | 1.10.3 | ایجاد بستر تست | 3d | 2019-05-15 | 2019-05-18 | 245 |  |  | 2021-09-30 | 2021-10-04 | 3d | 904d | 0d |  | 1398/02/25 | 1398/02/28 |
| 247 | 1.10.4 | تامین تجهیزات تست و راه اندازی | 7d | 2019-05-19 | 2019-05-26 | 246 |  |  | 2021-10-04 | 2021-10-12 | 7d | 904d |  |  | 1398/02/29 | 1398/03/05 |
| 248 | 1.10.5 | Routine tests customer for MCM | 130d | 2020-06-14 A | 2022-03-10 A |  | 100% |  | 2020-06-14 | 2022-03-10 | 130d |  |  |  | 1399/03/25 | 1400/12/19 |
| 249 | 1.11 | **محاسبات و پیاده سازی RAMS، LCC، FMECA و FTA** | 554d | 2020-01-21 A | 2021-10-27 |  | 27% | 403.87d | 2020-05-17 | 2022-03-10 | 568.15d | 145d |  |  | 1398/11/01 | 1400/08/05 |
| 250 | 1.11.1 | **RAMS** | 449.06d | 2020-05-17 A | 2021-10-23 |  | 6% | 420.82d | 2020-05-17 | 2021-08-31 | 404.65d | 146.94d |  |  | 1399/02/28 | 1400/08/01 |
| 251 | 1.11.1.1 | محاسبات Reliability | 55d | 2020-05-17 A | 2021-10-23 | 22FS+100d, 3 | 5% | 52.06d | 2020-05-17 | 2021-07-29 | 7d | 146.94d | 1.94d |  | 1399/02/28 | 1400/08/01 |
| 252 | 1.11.1.2 | محاسبات Availability | 49d | 2020-05-25 A | 2021-09-23 |  | 6% | 46.06d | 2020-05-25 | 2021-08-05 | 7d | 171.8d | 26.8d |  | 1399/03/05 | 1400/07/01 |
| 253 | 1.11.1.3 | محاسبات Maintenance | 44d | 2020-06-02 A | 2021-09-23 |  | 7% | 41.06d | 2020-06-02 | 2021-08-11 | 7d | 171.55d | 26.55d |  | 1399/03/13 | 1400/07/01 |
| 254 | 1.11.1.4 | محاسبات Saftey | 39d | 2020-06-10 A | 2021-09-23 |  | 8% | 36.06d | 2020-06-10 | 2021-08-17 | 7d | 171.65d | 26.65d |  | 1399/03/21 | 1400/07/01 |
| 255 | 1.11.2 | LCC | 393d | 2020-07-23 A | 2021-10-24 | 3 | 1% | 388.5d | 2020-07-23 | 2021-09-06 | 351.15d | 145d | 0d |  | 1399/05/02 | 1400/08/02 |

| ID | WBS | Task | Type | Duration | Start | Finish | Predecessors | Complete | Remaining | Baseline start | Baseline finish | Baseline duration | Total slack | Free slack | شروع | پایان |
| --- | --- | --- | --- | --- | --- | --- | --- | --- | --- | --- | --- | --- | --- | --- | --- | --- |
| 256 | 1.11.3 | **FMECA** |  | 521.09d | 2020-01-21 A | 2021-09-20 |  | 13% | 451.26d | 2020-08-03 | 2021-10-23 | 382.45d | 177.91d |  | 1398/11/01 | 1400/06/29 |
| 257 | 1.11.3.1 | انتخاب تجهیز برای مطالعه |  | 5d | 2020-01-21 A | 2021-08-24 | 22, 3 | 60% | 2d | 2020-08-03 | 2021-09-07 | 3d | 200d |  | 1398/11/01 | 1400/06/02 |
| 258 | 1.11.3.2 | جمع آوری اطلاعات عملکرد تجهیز |  | 1d | 2020-01-25 A | 2021-07-27 A | 257 | 100% |  | 2020-08-06 | 2021-09-12 | 5d |  |  | 1398/11/05 | 1400/05/05 |
| 259 | 1.11.3.3 | تعیین حالتهای خطای احتمالی که می تواند منجر به آسیب تجهیز شود |  | 10d | 2020-01-30 A | 2021-08-12 | 258 | 9% | 9.1d | 2020-08-12 | 2021-09-14 | 3d | 0d |  | 1398/11/10 | 1400/05/21 |
| 260 | 1.11.3.4 | شناسایی عوامل اصلی که در خطای تجهیز نقش دارند |  | 10d | 2020-02-03 A | 2021-08-23 | 259 | 9% | 9.1d | 2020-08-16 | 2021-09-16 | 3d | 0d |  | 1398/11/14 | 1400/06/01 |
| 261 | 1.11.3.5 | رتبه بندی هر حالت خطای تجهیز |  | 10d | 2020-02-06 A | 2021-09-04 | 260 | 9% | 9.1d | 2020-08-19 | 2021-09-19 | 3d | 174.91d | 0d | 1398/11/17 | 1400/06/13 |
| 262 | 1.11.3.6 | تخصیص رتبه شدت (نتیجه - توالی) به هر حالت خطا |  | 3d | 2021-09-04 | 2021-09-07 | 261 |  |  | 2021-09-19 | 2021-09-22 | 3d | 174.91d | 0d | 1400/06/13 | 1400/06/16 |
| 263 | 1.11.3.7 | ارزیابی سطح بحرانی خطای تجهیز و اولویت بندی حالتهای خرابی |  | 3d | 2021-09-07 | 2021-09-11 | 262 |  |  | 2021-09-22 | 2021-09-26 | 3d | 174.91d | 0d | 1400/06/16 | 1400/06/20 |
| 264 | 1.11.3.8 | طبقه بنیدی حالتهای خرابی به پنج سطح بحران |  | 3d | 2021-09-11 | 2021-09-14 | 263 |  |  | 2021-09-26 | 2021-09-29 | 3d | 174.91d | 0d | 1400/06/20 | 1400/06/23 |
| 265 | 1.11.3.9 | پیشنهاد اقدامات حفاظتی احتمالی برای جلوگیری از عود کردن خطا |  | 5d | 2021-09-14 | 2021-09-20 | 264 |  |  | 2021-09-29 | 2021-10-05 | 5d | 174.91d | 29.91d | 1400/06/23 | 1400/06/29 |
| 266 | 1.11.4 | FTA |  | 296d | 2020-10-13 A | 2021-09-22 | 3 | 77% | 67.2d | 2020-10-13 | 2022-03-10 | 440.15d | 172d | 27d | 1399/07/22 | 1400/06/31 |
| 267 | 1.11.5 | گزارش نهایی محاسبات و پیاده سازی RAMS، LCC، FMECA و FTA |  | 3d | 2021-10-25 | 2021-10-27 | 251, 252, 253, 254, 255, 265, 266 |  |  |  |  |  | 145d |  | 1400/08/03 | 1400/08/05 |
| 268 | 1.12 | **آموزش** |  | 60d | 2021-08-23 A | 2021-10-31 |  | 25% | 45d | 2021-06-15 | 2022-04-18 | 264d | 142d |  | 1400/06/01 | 1400/08/09 |
| 269 | 1.12.1 | Training of ACM |  | 60d | 2021-08-23 A | 2021-10-31 | 3 | 25% | 45d | 2022-02-08 | 2022-04-18 | 60d | 142d | 0d | 1400/06/01 | 1400/08/09 |
| 270 | 1.12.2 | Trainingof MCM |  | 60d | 2021-08-23 A | 2021-10-31 | 269SS | 25% | 45d | 2022-02-08 | 2022-04-18 | 60d | 142d | 0d | 1400/06/01 | 1400/08/09 |
| 271 | 1.12.3 | User Manual, IDU (3EST000215-2686) |  | 60d | 2021-08-23 A | 2021-10-31 | 270SS | 25% | 45d | 2022-02-08 | 2022-04-18 | 60d | 142d |  | 1400/06/01 | 1400/08/09 |
| 272 | 2 | پایان | milestone | 0d | 2022-04-14 | 2022-04-14 | 11, 12, 13, 14, 29, 40, 75, 106, 107, 108, 109, 110, 111, 112, 113, 114, 115, 124, 125, 126, 127, 146, 147, 148, 149, 150, 151, 152, 153, 166, 179, 180, 181, 182, 183, 184, 197, 198, 199, 200, 213, 224, 232, 234, 242, 248, 201 |  |  | 2022-04-14 | 2022-04-14 | 0d | 0d |  | 1401/01/25 | 1401/01/25 |
